Schedule from GanttProject, 2008-06-18 to 2009-03-31.

## Calendars

- Project calendar: Mon-Fri working; Sat-Sun off.

## Schedule

| ID | WBS | Task | Type | Duration | Start | Finish | Predecessors |
| --- | --- | --- | --- | --- | --- | --- | --- |
| 1 | 1 | **iGeoDesktop** |  | 205d | 2008-06-18 | 2009-03-31 |  |
| 2 | 1.1 | Style Editor |  | 75d | 2008-06-18 | 2008-09-30 |  |
| 3 | 1.2 | transaktionen auf WFS |  | 43d | 2008-08-01 | 2008-09-30 |  |
| 4 | 1.3 | Ausbau Digitalisierung |  | 131d | 2008-07-01 | 2008-12-30 |  |
| 5 | 1.4 | Druckfunktion |  | 22d | 2008-09-01 | 2008-09-30 |  |
| 6 | 1.5 | Bearbeitung der Layereigenschaften |  | 53d | 2008-06-18 | 2008-08-29 |  |
| 7 | 1.6 | erstes release | milestone | 0d | 2008-10-01 | 2008-10-01 | 2, 3, 5, 6 |
| 8 | 1.7 | Integration der deegree Config Tools |  | 65d | 2008-10-01 | 2008-12-30 |  |
| 9 | 1.8 | Migration auf deegree3 |  | 64d | 2009-01-01 | 2009-03-31 |  |
